Schedule from MS Project, 2026-02-21 to 2026-09-07, status date 2026-04-25, costs in ريال, A marks actual dates.

## Calendars

- Standard: Mon-Sun 08:00-12:00, 13:00-17:00.

## Schedule

| ID | WBS | Task | Type | Duration | Start | Finish | Predecessors | Complete | Remaining | Baseline start | Baseline finish | Baseline duration | Total slack | Constraint | Cost | Baseline cost | شروع | پایان | Duration. | Text4 | Text10 | Text11 | Text12 | Text13 |
| --- | --- | --- | --- | --- | --- | --- | --- | --- | --- | --- | --- | --- | --- | --- | --- | --- | --- | --- | --- | --- | --- | --- | --- | --- |
| 1 | 1 | **احداث پست سیار 63/20کیلوولت سیار شالباف** |  | 199d | 2026-02-21 A | 2026-09-07 |  | 1% | 197.75d | 2023-01-14 | 2026-03-20 | 1147d | 0d |  | 44,432.08 | 1,101,845.35 | 1404/12/2 | 1405/6/16 | 199days | 1402/3/21 | 1401/10/24 | 1403/4/23 | 1401/10/24 | 1403/5/3 |
| 2 | 1.1 | تاریخ ابلاغ قرارداد | milestone | 0d | 2026-02-21 A | 2026-02-21 A |  | 100% |  | 2023-01-14 | 2023-01-14 | 0d |  | finish no earlier than 2026-02-22 |  |  | 1404/12/2 | 1404/12/2 | 0days | 1401/8/21 | 1401/10/24 | 1401/10/24 | 1401/10/24 | 1401/10/24 |
| 3 | 1.2 | تاریخ شروع پروژه طبق قرارداد | milestone | 0d | 2026-03-07 | 2026-03-07 |  |  |  |  |  |  | 0d | start no earlier than 2026-03-07 |  |  | 1404/12/16 | 1404/12/16 | 0days |  |  |  |  |  |
| 4 | 1.3 | تحویل زمین | milestone | 0d | 2026-04-28 A | 2026-04-28 A |  | 100% |  | 2023-01-14 | 2023-01-14 | 0d |  | finish no earlier than 2026-02-09 |  |  | 1405/2/8 | 1405/2/8 | 0days |  | 1401/10/24 | 1401/10/24 | 1401/10/24 | 1401/10/24 |
| 5 | 1.4 | **طراحی و مهندسی** |  | 120d | 2026-02-21 A | 2026-06-20 |  |  | 120d | 2023-01-14 | 2025-11-21 | 1028d | 0d |  | 55.08 | 3,938.22 | 1404/12/2 | 1405/3/30 | 120days | 1401/11/20 | 1401/10/24 | 1402/6/31 | 1401/10/24 | 1402/10/7 |
| 6 | 1.4.1 | گزارش مقاومت الکتریکی خاک |  | 1d | 2026-02-21 A | 2026-02-21 | 2 |  | 1d | 2023-01-14 | 2023-01-14 | 0d | 11d |  |  |  | 1404/12/2 | 1404/12/2 | 1days | 1401/8/21 | 1401/10/24 | 1401/10/24 | 1401/10/24 | 1401/10/24 |
| 7 | 1.4.2 | طراحی سیستم زمین |  | 7d | 2026-02-22 A | 2026-02-28 | 2 |  | 7d | 2025-05-23 | 2025-05-23 | 0d | 0d | start no earlier than 2025-05-23 |  |  | 1404/12/3 | 1404/12/9 | 7days | 1401/8/21 | 1401/10/24 | 1401/10/24 | 1401/10/24 | 1401/10/24 |
| 8 | 1.4.3 | **بخش فشار قوی** |  | 77d | 2026-03-05 | 2026-05-20 |  |  |  | 2023-02-06 | 2025-11-16 | 1000d | 0d |  | 55.08 | 1,046.52 | 1404/12/14 | 1405/2/30 | 77days | 1401/10/26 | 1401/11/17 | 1402/6/31 | 1401/11/17 | 1402/8/29 |
| 9 | 1.4.3.1 | مدارک پایه |  | 52d | 2026-03-05 | 2026-04-25 | 6 |  |  |  |  |  | 0d | start no earlier than 2026-03-05 |  |  | 1404/12/14 | 1405/2/5 | 52days |  |  |  |  |  |
| 10 | 1.4.3.2 | **محاسبات** |  | 23d | 2026-04-26 | 2026-05-18 |  |  |  | 2023-04-09 | 2025-11-08 | 930d | 0d |  |  | 330.48 | 1405/2/6 | 1405/2/28 | 23days |  | 1402/1/20 | 1402/6/31 | 1402/3/8 | 1402/7/13 |
| 11 | 1.4.3.2.1 | **Earthing System Calculation** |  | 23d | 2026-04-26 | 2026-05-18 |  |  |  | 2023-06-11 | 2024-07-18 | 389d | 0d |  |  | 27.54 | 1405/2/6 | 1405/2/28 | 23days |  | 1402/3/21 | 1402/6/8 | 1402/3/8 | 1402/4/11 |
| 12 | 1.4.3.2.1.1 | Earthing System Calculation-طراحي اوليه مدرك |  | 4d | 2026-04-26 | 2026-04-29 | 9 |  |  |  |  |  | 0d |  |  |  | 1405/2/6 | 1405/2/9 | 4days |  |  |  |  |  |
| 13 | 1.4.3.2.1.2 | Earthing System Calculation-بررسي مدرك توسط مشاور |  | 6d | 2026-04-30 | 2026-05-05 | 12 |  |  |  |  |  | 0d |  |  |  | 1405/2/10 | 1405/2/15 | 6days |  |  |  |  |  |
| 14 | 1.4.3.2.1.3 | Earthing System Calculation-اصلاح مدرك |  | 7d | 2026-05-06 | 2026-05-12 | 13 |  |  |  |  |  | 0d |  |  |  | 1405/2/16 | 1405/2/22 | 7days |  |  |  |  |  |
| 15 | 1.4.3.2.1.4 | Earthing System Calculation-تاييد مدرك توسط مشاور |  | 6d | 2026-05-13 | 2026-05-18 | 14 |  |  |  |  |  | 0d |  |  |  | 1405/2/23 | 1405/2/28 | 6days |  |  |  |  |  |
| 16 | 1.4.3.3 | **نقشه ها** |  | 25d | 2026-04-26 | 2026-05-20 |  |  |  | 2023-08-13 | 2025-11-07 | 803d | 0d |  |  | 220.32 | 1405/2/6 | 1405/2/30 | 25days | 1401/10/12 | 1402/5/22 | 1402/6/29 | 1402/3/23 | 1402/6/31 |
| 17 | 1.4.3.3.1 | **Earthing System Plan & Detail Drawings** |  | 25d | 2026-04-26 | 2026-05-20 |  |  |  | 2024-07-14 | 2024-08-02 | 20d | 0d |  |  | 27.54 | 1405/2/6 | 1405/2/30 | 25days | 1401/9/14 | 1402/6/4 | 1402/6/23 | 1402/5/11 | 1402/6/10 |
| 18 | 1.4.3.3.1.1 | Earthing System Plan & Detail Drawings-طراحي اوليه مدرك |  | 6d | 2026-04-26 | 2026-05-01 | 9 |  |  |  |  |  | 0d |  |  |  | 1405/2/6 | 1405/2/11 | 6days |  |  |  |  |  |
| 19 | 1.4.3.3.1.2 | Earthing System Plan & Detail Drawings-بررسي مدرك توسط مشاور |  | 6d | 2026-05-02 | 2026-05-07 | 18 |  |  |  |  |  | 0d |  |  |  | 1405/2/12 | 1405/2/17 | 6days |  |  |  |  |  |
| 20 | 1.4.3.3.1.3 | Earthing System Plan & Detail Drawings-اصلاح مدرك |  | 7d | 2026-05-08 | 2026-05-14 | 19 |  |  |  |  |  | 0d |  |  |  | 1405/2/18 | 1405/2/24 | 7days |  |  |  |  |  |
| 21 | 1.4.3.3.1.4 | Earthing System Plan & Detail Drawings-تاييد مدرك توسط مشاور |  | 6d | 2026-05-15 | 2026-05-20 | 20 |  |  |  |  |  | 0d |  |  |  | 1405/2/25 | 1405/2/30 | 6days |  |  |  |  |  |
| 22 | 1.4.3.3.2 | **Switchyard Panel Arrangement Drawings** |  | 25d | 2026-04-26 | 2026-05-20 |  |  |  | 2025-06-10 | 2025-08-08 | 60d | 0d |  |  | 27.54 | 1405/2/6 | 1405/2/30 | 25days | 1401/9/7 | 1402/6/8 | 1402/6/18 | 1402/3/23 | 1402/4/22 |
| 23 | 1.4.3.3.2.1 | Cable Ladder Arrangment & Detail Drawings-طراحي اوليه مدرك |  | 6d | 2026-04-26 | 2026-05-01 | 9 |  |  |  |  |  | 0d |  |  |  | 1405/2/6 | 1405/2/11 | 6days |  |  |  |  |  |
| 24 | 1.4.3.3.2.2 | Cable Ladder Arrangment & Detail Drawings-بررسي مدرك توسط مشاور |  | 6d | 2026-05-02 | 2026-05-07 | 23 |  |  |  |  |  | 0d |  |  |  | 1405/2/12 | 1405/2/17 | 6days |  |  |  |  |  |
| 25 | 1.4.3.3.2.3 | Cable Ladder Arrangment & Detail Drawings-اصلاح مدرك |  | 7d | 2026-05-08 | 2026-05-14 | 24 |  |  |  |  |  | 0d |  |  |  | 1405/2/18 | 1405/2/24 | 7days |  |  |  |  |  |
| 26 | 1.4.3.3.2.4 | Cable Ladder Arrangment & Detail Drawings-تاييد مدرك توسط مشاور |  | 6d | 2026-05-15 | 2026-05-20 | 25 |  |  |  |  |  | 0d |  |  |  | 1405/2/25 | 1405/2/30 | 6days |  |  |  |  |  |

| ID | WBS | Task | Duration | Start | Finish | Predecessors | Baseline start | Baseline finish | Baseline duration | Total slack | Constraint | Cost | Baseline cost | شروع | پایان | Duration. | Text4 | Text10 | Text11 | Text12 | Text13 | Text30 |
| --- | --- | --- | --- | --- | --- | --- | --- | --- | --- | --- | --- | --- | --- | --- | --- | --- | --- | --- | --- | --- | --- | --- |
| 27 | 1.4.3.4 | **مشخصات فنی تجهیزات** | 25d | 2026-04-26 | 2026-05-20 |  | 2023-04-12 | 2025-11-16 | 935d | 0d |  | 55.08 | 440.64 | 1405/2/6 | 1405/2/30 | 25days | 1401/10/26 | 1402/1/23 | 1402/6/31 | 1402/2/1 | 1402/8/29 |  |
| 28 | 1.4.3.4.1 | **MV Panels Technical Specification** | 25d | 2026-04-26 | 2026-05-20 |  | 2025-10-05 | 2025-11-01 | 28d | 0d |  | 27.54 | 27.54 | 1405/2/6 | 1405/2/30 | 25days |  | 1402/6/1 | 1402/6/28 | 1402/3/15 | 1402/4/11 |  |
| 29 | 1.4.3.4.1.1 | MV Panels Technical Specification-طراحي اوليه مدرك | 6d | 2026-04-26 | 2026-05-01 | 9 | 2025-10-05 | 2025-10-11 | 7d | 0d | start no earlier than 2026-04-21 | 13.77 | 13.77 | 1405/2/6 | 1405/2/11 | 6days |  | 1402/6/1 | 1402/6/7 | 1402/3/15 | 1402/3/21 |  |
| 30 | 1.4.3.4.1.2 | MV Panels Technical Specification-بررسي مدرك توسط مشاور | 6d | 2026-05-02 | 2026-05-07 | 29 | 2025-10-12 | 2025-10-18 | 7d | 0d | start no earlier than 2025-10-04 | 6.89 | 6.89 | 1405/2/12 | 1405/2/17 | 6days |  | 1402/6/8 | 1402/6/14 | 1402/3/22 | 1402/3/28 |  |
| 31 | 1.4.3.4.1.3 | MV Panels Technical Specification-اصلاح مدرك | 7d | 2026-05-08 | 2026-05-14 | 30 | 2025-10-19 | 2025-10-25 | 7d | 0d | start no earlier than 2025-10-04 | 2.75 | 2.75 | 1405/2/18 | 1405/2/24 | 7days |  | 1402/6/15 | 1402/6/21 | 1402/3/29 | 1402/4/4 |  |
| 32 | 1.4.3.4.1.4 | MV Panels Technical Specification-تاييد مدرك توسط مشاور | 6d | 2026-05-15 | 2026-05-20 | 31 | 2025-10-26 | 2025-11-01 | 7d | 0d | start no earlier than 2025-10-04 | 4.13 | 4.13 | 1405/2/25 | 1405/2/30 | 6days |  | 1402/6/22 | 1402/6/28 | 1402/4/5 | 1402/4/11 |  |
| 33 | 1.4.3.4.2 | **Earthing System Equipment & Temporary Earthing Devices Specification** | 25d | 2026-04-26 | 2026-05-20 |  | 2025-10-05 | 2025-10-29 | 25d | 0d |  | 27.54 | 27.54 | 1405/2/6 | 1405/2/30 | 25days | 1401/9/21 | 1402/6/14 | 1402/6/31 | 1402/7/17 | 1402/8/14 |  |
| 34 | 1.4.3.4.2.1 | Earthing System Equipment & Temporary Earthing Devices Specification-طراحي اوليه مدرك | 6d | 2026-04-26 | 2026-05-01 | 9 | 2025-10-05 | 2025-10-06 | 2d | 0d | start no earlier than 2026-02-21 | 13.77 | 13.77 | 1405/2/6 | 1405/2/11 | 6days |  | 1402/6/14 | 1402/6/15 | 1402/7/17 | 1402/7/23 |  |
| 35 | 1.4.3.4.2.2 | Earthing System Equipment & Temporary Earthing Devices Specification-بررسي مدرك توسط مشاور | 6d | 2026-05-02 | 2026-05-07 | 34 | 2025-10-07 | 2025-10-13 | 7d | 0d | start no earlier than 2025-10-04 | 6.89 | 6.89 | 1405/2/12 | 1405/2/17 | 6days |  | 1402/6/16 | 1402/6/22 | 1402/7/24 | 1402/7/30 |  |
| 36 | 1.4.3.4.2.3 | Earthing System Equipment & Temporary Earthing Devices Specification-اصلاح مدرك | 7d | 2026-05-08 | 2026-05-14 | 35 | 2025-10-14 | 2025-10-15 | 2d | 0d | start no earlier than 2025-10-04 | 2.75 | 2.75 | 1405/2/18 | 1405/2/24 | 7days |  | 1402/6/23 | 1402/6/24 | 1402/8/1 | 1402/8/7 |  |
| 37 | 1.4.3.4.2.4 | Earthing System Equipment & Temporary Earthing Devices Specification-تاييد مدرك توسط مشاور | 6d | 2026-05-15 | 2026-05-20 | 36 | 2025-10-16 | 2025-10-29 | 14d | 0d | start no earlier than 2025-10-04 | 4.13 | 4.13 | 1405/2/25 | 1405/2/30 | 6days |  | 1402/6/25 | 1402/6/31 | 1402/8/8 | 1402/8/14 |  |
| 38 | 1.4.4 | **بخش فشار ضعیف** | 60d | 2026-04-22 | 2026-06-20 |  | 2023-02-26 | 2025-11-21 | 985d | 0d |  |  | 1,569.78 | 1405/2/2 | 1405/3/30 | 60days | 1401/11/20 | 1401/10/24 | 1402/6/31 | 1401/12/7 | 1402/10/7 |  |
| 39 | 1.4.4.1 | **مدارک پایه** | 19d | 2026-04-22 | 2026-05-10 |  | 2023-02-26 | 2025-11-21 | 985d | 0d |  |  | 550.8 | 1405/2/2 | 1405/2/20 | 19days | 1401/9/30 | 1401/12/7 | 1402/5/28 | 1401/12/7 | 1402/7/5 |  |
| 40 | 1.4.4.1.1 | **Protection & Metering Single Line Diagram** | 19d | 2026-04-22 | 2026-05-10 |  | 2023-02-26 | 2023-03-25 | 28d | 0d |  |  | 27.54 | 1405/2/2 | 1405/2/20 | 19days | 1401/8/28 | 1401/12/7 | 1402/1/5 | 1401/12/7 | 1402/1/10 | A1 |
| 41 | 1.4.4.1.1.1 | Protection & Metering Single Line Diagram -طراحي اوليه مدرك | 7d | 2026-04-22 | 2026-04-28 | 2FS+60d |  |  |  | 0d |  |  |  | 1405/2/2 | 1405/2/8 | 7days |  |  |  |  |  |  |
| 42 | 1.4.4.1.1.2 | Protection & Metering Single Line Diagram -بررسي مدرك توسط مشاور | 6d | 2026-04-29 | 2026-05-04 | 41 |  |  |  | 0d |  |  |  | 1405/2/9 | 1405/2/14 | 6days |  |  |  |  |  |  |
| 43 | 1.4.4.1.1.3 | Protection & Metering Single Line Diagram -اصلاح مدرك | 3d | 2026-05-05 | 2026-05-07 | 42 |  |  |  | 0d |  |  |  | 1405/2/15 | 1405/2/17 | 3days |  |  |  |  |  |  |
| 44 | 1.4.4.1.1.4 | Protection & Metering Single Line Diagram -تاييد مدرك توسط مشاور | 3d | 2026-05-08 | 2026-05-10 | 43 |  |  |  | 0d |  |  |  | 1405/2/18 | 1405/2/20 | 3days |  |  |  |  |  |  |
| 45 | 1.4.4.1.2 | **Control Logic Diagram** | 19d | 2026-04-22 | 2026-05-10 |  | 2023-03-28 | 2023-04-27 | 31d | 0d |  |  | 27.54 | 1405/2/2 | 1405/2/20 | 19days | 1401/9/5 | 1402/1/8 | 1402/2/7 | 1402/1/13 | 1402/2/12 | A2 |
| 46 | 1.4.4.1.2.1 | Control Logic Diagram-طراحي اوليه مدرك | 7d | 2026-04-22 | 2026-04-28 | 2FS+60d |  |  |  | 0d |  |  |  | 1405/2/2 | 1405/2/8 | 7days |  |  |  |  |  |  |
| 47 | 1.4.4.1.2.2 | Control Logic Diagram-بررسي مدرك توسط مشاور | 6d | 2026-04-29 | 2026-05-04 | 46 |  |  |  | 0d |  |  |  | 1405/2/9 | 1405/2/14 | 6days |  |  |  |  |  |  |
| 48 | 1.4.4.1.2.3 | Control Logic Diagram-اصلاح مدرك | 3d | 2026-05-05 | 2026-05-07 | 47 |  |  |  | 0d |  |  |  | 1405/2/15 | 1405/2/17 | 3days |  |  |  |  |  |  |
| 49 | 1.4.4.1.2.4 | Control Logic Diagram-تاييد مدرك توسط مشاور | 3d | 2026-05-08 | 2026-05-10 | 48 |  |  |  | 0d |  |  |  | 1405/2/18 | 1405/2/20 | 3days |  |  |  |  |  |  |
| 50 | 1.4.4.1.3 | **AVR Logic Diagram** | 19d | 2026-04-22 | 2026-05-10 |  | 2023-03-28 | 2025-10-18 | 921d | 0d |  |  | 27.54 | 1405/2/2 | 1405/2/20 | 19days | 1401/9/5 | 1402/1/8 | 1402/2/7 | 1402/1/13 | 1402/2/12 | A3 |
| 51 | 1.4.4.1.3.1 | AVR Logic Diagram-طراحي اوليه مدرك | 7d | 2026-04-22 | 2026-04-28 | 2FS+60d |  |  |  | 0d |  |  |  | 1405/2/2 | 1405/2/8 | 7days |  |  |  |  |  |  |
| 52 | 1.4.4.1.3.2 | AVR Logic Diagram-بررسي مدرك توسط مشاور | 6d | 2026-04-29 | 2026-05-04 | 51 |  |  |  | 0d |  |  |  | 1405/2/9 | 1405/2/14 | 6days |  |  |  |  |  |  |
| 53 | 1.4.4.1.3.3 | AVR Logic Diagram-اصلاح مدرك | 3d | 2026-05-05 | 2026-05-07 | 52 |  |  |  | 0d |  |  |  | 1405/2/15 | 1405/2/17 | 3days |  |  |  |  |  |  |
| 54 | 1.4.4.1.3.4 | AVR Logic Diagram-تاييد مدرك توسط مشاور | 3d | 2026-05-08 | 2026-05-10 | 53 |  |  |  | 0d |  |  |  | 1405/2/18 | 1405/2/20 | 3days |  |  |  |  |  |  |

| ID | WBS | Task | Duration | Start | Finish | Predecessors | Baseline start | Baseline finish | Baseline duration | Total slack | Constraint | Baseline cost | شروع | پایان | Duration. | Text4 | Text10 | Text11 | Text12 | Text13 | Text30 |
| --- | --- | --- | --- | --- | --- | --- | --- | --- | --- | --- | --- | --- | --- | --- | --- | --- | --- | --- | --- | --- | --- |
| 55 | 1.4.4.1.4 | **Protection Trip Matrix** | 19d | 2026-04-22 | 2026-05-10 |  | 2023-04-25 | 2023-05-16 | 22d | 0d |  | 27.54 | 1405/2/2 | 1405/2/20 | 19days | 1401/9/3 | 1402/2/5 | 1402/2/26 | 1402/2/10 | 1402/2/31 | A4 |
| 56 | 1.4.4.1.4.1 | Protection Trip Matrix-طراحي اوليه مدرك | 7d | 2026-04-22 | 2026-04-28 | 2FS+60d |  |  |  | 0d | start no earlier than 2023-01-14 |  | 1405/2/2 | 1405/2/8 | 7days |  |  |  |  |  |  |
| 57 | 1.4.4.1.4.2 | Protection Trip Matrix-بررسي مدرك توسط مشاور | 6d | 2026-04-29 | 2026-05-04 | 56 |  |  |  | 0d |  |  | 1405/2/9 | 1405/2/14 | 6days |  |  |  |  |  |  |
| 58 | 1.4.4.1.4.3 | Protection Trip Matrix-اصلاح مدرك | 3d | 2026-05-05 | 2026-05-07 | 57 |  |  |  | 0d |  |  | 1405/2/15 | 1405/2/17 | 3days |  |  |  |  |  |  |
| 59 | 1.4.4.1.4.4 | Protection Trip Matrix-تاييد مدرك توسط مشاور | 3d | 2026-05-08 | 2026-05-10 | 58 |  |  |  | 0d |  |  | 1405/2/18 | 1405/2/20 | 3days |  |  |  |  |  |  |
| 60 | 1.4.4.1.5 | **Signal & Alarm List** | 19d | 2026-04-22 | 2026-05-10 |  | 2023-04-16 | 2023-05-06 | 21d | 0d |  | 27.54 | 1405/2/2 | 1405/2/20 | 19days | 1401/9/17 | 1402/1/27 | 1402/2/16 | 1402/2/10 | 1402/2/30 | A5 |
| 61 | 1.4.4.1.5.1 | Signal & Alarm List-طراحي اوليه مدرك | 7d | 2026-04-22 | 2026-04-28 | 2FS+60d |  |  |  | 0d |  |  | 1405/2/2 | 1405/2/8 | 7days |  |  |  |  |  |  |
| 62 | 1.4.4.1.5.2 | Signal & Alarm List-بررسي مدرك توسط مشاور | 6d | 2026-04-29 | 2026-05-04 | 61 |  |  |  | 0d |  |  | 1405/2/9 | 1405/2/14 | 6days |  |  |  |  |  |  |
| 63 | 1.4.4.1.5.3 | Signal & Alarm List-اصلاح مدرك | 3d | 2026-05-05 | 2026-05-07 | 62 |  |  |  | 0d |  |  | 1405/2/15 | 1405/2/17 | 3days |  |  |  |  |  |  |
| 64 | 1.4.4.1.5.4 | Signal & Alarm List-تاييد مدرك توسط مشاور | 3d | 2026-05-08 | 2026-05-10 | 63 |  |  |  | 0d |  |  | 1405/2/18 | 1405/2/20 | 3days |  |  |  |  |  |  |
| 65 | 1.4.4.1.6 | **Protection & Measuring Panels Front View** | 19d | 2026-04-22 | 2026-05-10 |  | 2023-05-07 | 2025-10-18 | 881d | 0d |  | 27.54 | 1405/2/2 | 1405/2/20 | 19days | 1401/9/10 | 1402/2/17 | 1402/3/14 | 1402/3/14 | 1402/4/11 | A6 |
| 66 | 1.4.4.1.6.1 | Protection & Measuring Panels Front View-طراحي اوليه مدرك | 7d | 2026-04-22 | 2026-04-28 | 2FS+60d |  |  |  | 0d |  |  | 1405/2/2 | 1405/2/8 | 7days |  |  |  |  |  |  |
| 67 | 1.4.4.1.6.2 | Protection & Measuring Panels Front View-بررسي مدرك توسط مشاور | 6d | 2026-04-29 | 2026-05-04 | 66 |  |  |  | 0d |  |  | 1405/2/9 | 1405/2/14 | 6days |  |  |  |  |  |  |
| 68 | 1.4.4.1.6.3 | Protection & Measuring Panels Front View-اصلاح مدرك | 3d | 2026-05-05 | 2026-05-07 | 67 |  |  |  | 0d |  |  | 1405/2/15 | 1405/2/17 | 3days |  |  |  |  |  |  |
| 69 | 1.4.4.1.6.4 | Protection & Measuring Panels Front View-تاييد مدرك توسط مشاور | 3d | 2026-05-08 | 2026-05-10 | 68 |  |  |  | 0d |  |  | 1405/2/18 | 1405/2/20 | 3days |  |  |  |  |  |  |
| 70 | 1.4.4.1.7 | **Common BUC & AVR & Outdoor Marshaling Panels Front View** | 19d | 2026-04-22 | 2026-05-10 |  | 2023-05-12 | 2025-10-30 | 888d | 0d |  | 27.54 | 1405/2/2 | 1405/2/20 | 19days | 1401/9/12 | 1402/2/22 | 1402/3/15 | 1402/3/30 | 1402/4/23 | A7 |
| 71 | 1.4.4.1.7.1 | Common BUC & AVR & Outdoor Marshaling Panels Front View-طراحي اوليه مدرك | 7d | 2026-04-22 | 2026-04-28 | 2FS+60d |  |  |  | 0d |  |  | 1405/2/2 | 1405/2/8 | 7days |  |  |  |  |  |  |
| 72 | 1.4.4.1.7.2 | Common BUC & AVR & Outdoor Marshaling Panels Front View-بررسي مدرك توسط مشاور | 6d | 2026-04-29 | 2026-05-04 | 71 |  |  |  | 0d |  |  | 1405/2/9 | 1405/2/14 | 6days |  |  |  |  |  |  |
| 73 | 1.4.4.1.7.3 | Common BUC & AVR & Outdoor Marshaling Panels Front View-اصلاح مدرك | 3d | 2026-05-05 | 2026-05-07 | 72 |  |  |  | 0d |  |  | 1405/2/15 | 1405/2/17 | 3days |  |  |  |  |  |  |
| 74 | 1.4.4.1.7.4 | Common BUC & AVR & Outdoor Marshaling Panels Front View-تاييد مدرك توسط مشاور | 3d | 2026-05-08 | 2026-05-10 | 73 |  |  |  | 0d |  |  | 1405/2/18 | 1405/2/20 | 3days |  |  |  |  |  |  |
| 75 | 1.4.4.1.8 | **YV & HVI & RTU & PLC Panels Front View** | 19d | 2026-04-22 | 2026-05-10 |  | 2025-10-19 | 2025-11-21 | 34d | 0d |  | 27.54 | 1405/2/2 | 1405/2/20 | 19days | 1401/9/12 | 1402/3/9 | 1402/5/9 | 1402/3/14 | 1402/5/14 | A8 |
| 76 | 1.4.4.1.8.1 | YV & HVI & RTU & PLC Panels Front View-طراحي اوليه مدرك | 7d | 2026-04-22 | 2026-04-28 | 2FS+60d |  |  |  | 0d |  |  | 1405/2/2 | 1405/2/8 | 7days |  |  |  |  |  |  |
| 77 | 1.4.4.1.8.2 | YV & HVI & RTU & PLC Panels Front View-بررسي مدرك توسط مشاور | 6d | 2026-04-29 | 2026-05-04 | 76 |  |  |  | 0d |  |  | 1405/2/9 | 1405/2/14 | 6days |  |  |  |  |  |  |
| 78 | 1.4.4.1.8.3 | YV & HVI & RTU & PLC Panels Front View-اصلاح مدرك | 3d | 2026-05-05 | 2026-05-07 | 77 |  |  |  | 0d |  |  | 1405/2/15 | 1405/2/17 | 3days |  |  |  |  |  |  |
| 79 | 1.4.4.1.8.4 | YV & HVI & RTU & PLC Panels Front View-تاييد مدرك توسط مشاور | 3d | 2026-05-08 | 2026-05-10 | 78 |  |  |  | 0d |  |  | 1405/2/18 | 1405/2/20 | 3days |  |  |  |  |  |  |

| ID | WBS | Task | Duration | Start | Finish | Predecessors | Baseline start | Baseline finish | Baseline duration | Total slack | Baseline cost | شروع | پایان | Duration. | Text10 | Text11 | Text12 | Text13 | Text30 | Text4 |
| --- | --- | --- | --- | --- | --- | --- | --- | --- | --- | --- | --- | --- | --- | --- | --- | --- | --- | --- | --- | --- |
| 80 | 1.4.4.1.9 | **MV Switchgear Panels Front View** | 19d | 2026-04-22 | 2026-05-10 |  | 2025-10-05 | 2025-11-11 | 38d | 0d | 27.54 | 1405/2/2 | 1405/2/20 | 19days | 1402/2/17 | 1402/3/15 | 1402/2/31 | 1402/3/29 | A9 |  |
| 81 | 1.4.4.1.9.1 | MV Switchgear Panels Front View-طراحي اوليه مدرك | 7d | 2026-04-22 | 2026-04-28 | 2FS+60d |  |  |  | 0d |  | 1405/2/2 | 1405/2/8 | 7days |  |  |  |  |  |  |
| 82 | 1.4.4.1.9.2 | MV Switchgear Panels Front View-بررسي مدرك توسط مشاور | 6d | 2026-04-29 | 2026-05-04 | 81 |  |  |  | 0d |  | 1405/2/9 | 1405/2/14 | 6days |  |  |  |  |  |  |
| 83 | 1.4.4.1.9.3 | MV Switchgear Panels Front View-اصلاح مدرك | 3d | 2026-05-05 | 2026-05-07 | 82 |  |  |  | 0d |  | 1405/2/15 | 1405/2/17 | 3days |  |  |  |  |  |  |
| 84 | 1.4.4.1.9.4 | MV Switchgear Panels Front View-تاييد مدرك توسط مشاور | 3d | 2026-05-08 | 2026-05-10 | 83 |  |  |  | 0d |  | 1405/2/18 | 1405/2/20 | 3days |  |  |  |  |  |  |
| 85 | 1.4.4.1.10 | **LVAC System Single Line Diagram** | 19d | 2026-04-22 | 2026-05-10 |  | 2023-06-06 | 2023-06-24 | 19d | 0d | 27.54 | 1405/2/2 | 1405/2/20 | 19days | 1402/3/16 | 1402/4/3 | 1402/4/24 | 1402/5/11 | A11 | 1401/9/9 |
| 86 | 1.4.4.1.10.1 | LVAC System Single Line Diagram-طراحي اوليه مدرك | 7d | 2026-04-22 | 2026-04-28 | 2FS+60d |  |  |  | 0d |  | 1405/2/2 | 1405/2/8 | 7days |  |  |  |  |  |  |
| 87 | 1.4.4.1.10.2 | LVAC System Single Line Diagram-بررسي مدرك توسط مشاور | 6d | 2026-04-29 | 2026-05-04 | 86 |  |  |  | 0d |  | 1405/2/9 | 1405/2/14 | 6days |  |  |  |  |  |  |
| 88 | 1.4.4.1.10.3 | LVAC System Single Line Diagram-اصلاح مدرك | 3d | 2026-05-05 | 2026-05-07 | 87 |  |  |  | 0d |  | 1405/2/15 | 1405/2/17 | 3days |  |  |  |  |  |  |
| 89 | 1.4.4.1.10.4 | LVAC System Single Line Diagram-تاييد مدرك توسط مشاور | 3d | 2026-05-08 | 2026-05-10 | 88 |  |  |  | 0d |  | 1405/2/18 | 1405/2/20 | 3days |  |  |  |  |  |  |
| 90 | 1.4.4.1.11 | **LVAC System Logic Diagram** | 19d | 2026-04-22 | 2026-05-10 |  | 2023-06-25 | 2023-07-12 | 18d | 0d | 27.54 | 1405/2/2 | 1405/2/20 | 19days | 1402/4/4 | 1402/4/21 | 1402/5/12 | 1402/5/29 | A12 | 1401/9/9 |
| 91 | 1.4.4.1.11.1 | LVAC System Logic Diagram-طراحي اوليه مدرك | 7d | 2026-04-22 | 2026-04-28 | 2FS+60d |  |  |  | 0d |  | 1405/2/2 | 1405/2/8 | 7days |  |  |  |  |  |  |
| 92 | 1.4.4.1.11.2 | LVAC System Logic Diagram-بررسي مدرك توسط مشاور | 6d | 2026-04-29 | 2026-05-04 | 91 |  |  |  | 0d |  | 1405/2/9 | 1405/2/14 | 6days |  |  |  |  |  |  |
| 93 | 1.4.4.1.11.3 | LVAC System Logic Diagram-اصلاح مدرك | 3d | 2026-05-05 | 2026-05-07 | 92 |  |  |  | 0d |  | 1405/2/15 | 1405/2/17 | 3days |  |  |  |  |  |  |
| 94 | 1.4.4.1.11.4 | LVAC System Logic Diagram-تاييد مدرك توسط مشاور | 3d | 2026-05-08 | 2026-05-10 | 93 |  |  |  | 0d |  | 1405/2/18 | 1405/2/20 | 3days |  |  |  |  |  |  |
| 95 | 1.4.4.1.12 | **LVDC System Single Line Diagram** | 19d | 2026-04-22 | 2026-05-10 |  | 2023-05-07 | 2025-10-09 | 872d | 0d | 27.54 | 1405/2/2 | 1405/2/20 | 19days | 1402/2/17 | 1402/3/6 | 1402/2/31 | 1402/3/20 | A13 | 1401/9/9 |
| 96 | 1.4.4.1.12.1 | LVDC System Single Line Diagram-طراحي اوليه مدرك | 7d | 2026-04-22 | 2026-04-28 | 2FS+60d |  |  |  | 0d |  | 1405/2/2 | 1405/2/8 | 7days |  |  |  |  |  |  |
| 97 | 1.4.4.1.12.2 | LVDC System Single Line Diagram-بررسي مدرك توسط مشاور | 6d | 2026-04-29 | 2026-05-04 | 96 |  |  |  | 0d |  | 1405/2/9 | 1405/2/14 | 6days |  |  |  |  |  |  |
| 98 | 1.4.4.1.12.3 | LVDC System Single Line Diagram-اصلاح مدرك | 3d | 2026-05-05 | 2026-05-07 | 97 |  |  |  | 0d |  | 1405/2/15 | 1405/2/17 | 3days |  |  |  |  |  |  |
| 99 | 1.4.4.1.12.4 | LVDC System Single Line Diagram-تاييد مدرك توسط مشاور | 3d | 2026-05-08 | 2026-05-10 | 98 |  |  |  | 0d |  | 1405/2/18 | 1405/2/20 | 3days |  |  |  |  |  |  |
| 100 | 1.4.4.1.13 | **LVDC System Logic Diagram** | 19d | 2026-04-22 | 2026-05-10 |  | 2023-05-28 | 2025-10-19 | 860.8d | 0d | 27.54 | 1405/2/2 | 1405/2/20 | 19days | 1402/3/7 | 1402/4/3 | 1402/3/21 | 1402/4/17 | A15 | 1401/9/9 |
| 101 | 1.4.4.1.13.1 | LVDC System Logic Diagram-طراحي اوليه مدرك | 7d | 2026-04-22 | 2026-04-28 | 2FS+60d |  |  |  | 0d |  | 1405/2/2 | 1405/2/8 | 7days |  |  |  |  |  |  |
| 102 | 1.4.4.1.13.2 | LVDC System Logic Diagram-بررسي مدرك توسط مشاور | 6d | 2026-04-29 | 2026-05-04 | 101 |  |  |  | 0d |  | 1405/2/9 | 1405/2/14 | 6days |  |  |  |  |  |  |
| 103 | 1.4.4.1.13.3 | LVDC System Logic Diagram-اصلاح مدرك | 3d | 2026-05-05 | 2026-05-07 | 102 |  |  |  | 0d |  | 1405/2/15 | 1405/2/17 | 3days |  |  |  |  |  |  |
| 104 | 1.4.4.1.13.4 | LVDC System Logic Diagram-تاييد مدرك توسط مشاور | 3d | 2026-05-08 | 2026-05-10 | 103 |  |  |  | 0d |  | 1405/2/18 | 1405/2/20 | 3days |  |  |  |  |  |  |

| ID | WBS | Task | Duration | Start | Finish | Predecessors | Baseline start | Baseline finish | Baseline duration | Total slack | Baseline cost | شروع | پایان | Duration. | Text4 | Text10 | Text11 | Text12 | Text13 | Text30 |
| --- | --- | --- | --- | --- | --- | --- | --- | --- | --- | --- | --- | --- | --- | --- | --- | --- | --- | --- | --- | --- |
| 105 | 1.4.4.1.14 | **48VDC System Logic Diagram** | 19d | 2026-04-22 | 2026-05-10 |  | 2023-07-13 | 2025-10-12 | 808d | 0d | 27.54 | 1405/2/2 | 1405/2/20 | 19days | 1401/9/9 | 1402/4/22 | 1402/5/10 | 1402/5/30 | 1402/6/18 | A16 |
| 106 | 1.4.4.1.14.1 | 48VDC System Logic Diagram-طراحي اوليه مدرك | 7d | 2026-04-22 | 2026-04-28 | 2FS+60d |  |  |  | 0d |  | 1405/2/2 | 1405/2/8 | 7days |  |  |  |  |  |  |
| 107 | 1.4.4.1.14.2 | 48VDC System Logic Diagram-بررسي مدرك توسط مشاور | 6d | 2026-04-29 | 2026-05-04 | 106 |  |  |  | 0d |  | 1405/2/9 | 1405/2/14 | 6days |  |  |  |  |  |  |
| 108 | 1.4.4.1.14.3 | 48VDC System Logic Diagram-اصلاح مدرك | 3d | 2026-05-05 | 2026-05-07 | 107 |  |  |  | 0d |  | 1405/2/15 | 1405/2/17 | 3days |  |  |  |  |  |  |
| 109 | 1.4.4.1.14.4 | 48VDC System Logic Diagram-تاييد مدرك توسط مشاور | 3d | 2026-05-08 | 2026-05-10 | 108 |  |  |  | 0d |  | 1405/2/18 | 1405/2/20 | 3days |  |  |  |  |  |  |
| 110 | 1.4.4.1.15 | **Control & Switchgear Room Panel Arrangment** | 19d | 2026-04-22 | 2026-05-10 |  | 2024-08-13 | 2025-07-12 | 333.55d | 0d | 27.54 | 1405/2/2 | 1405/2/20 | 19days | 1401/9/24 | 1402/3/16 | 1402/3/30 | 1402/4/24 | 1402/5/7 | A18 |
| 111 | 1.4.4.1.15.1 | Control & Switchgear Room Panel Arrangment-طراحي اوليه مدرك | 7d | 2026-04-22 | 2026-04-28 | 2FS+60d |  |  |  | 0d |  | 1405/2/2 | 1405/2/8 | 7days |  |  |  |  |  |  |
| 112 | 1.4.4.1.15.2 | Control & Switchgear Room Panel Arrangment-بررسي مدرك توسط مشاور | 6d | 2026-04-29 | 2026-05-04 | 111 |  |  |  | 0d |  | 1405/2/9 | 1405/2/14 | 6days |  |  |  |  |  |  |
| 113 | 1.4.4.1.15.3 | Control & Switchgear Room Panel Arrangment-اصلاح مدرک | 3d | 2026-05-05 | 2026-05-07 | 112 |  |  |  | 0d |  | 1405/2/15 | 1405/2/17 | 3days |  |  |  |  |  |  |
| 114 | 1.4.4.1.15.4 | Control & Switchgear Room Panel Arrangment-تاييد مدرك توسط مشاور | 3d | 2026-05-08 | 2026-05-10 | 113 |  |  |  | 0d |  | 1405/2/18 | 1405/2/20 | 3days |  |  |  |  |  |  |
| 115 | 1.4.4.2 | **جزئیات اسکماتیک** | 16d | 2026-05-11 | 2026-05-26 |  | 2023-08-27 | 2025-11-19 | 801d | 0d | 468.18 | 1405/2/21 | 1405/3/5 | 16days | 1401/10/8 | 1402/6/5 | 1402/6/28 | 1402/4/12 | 1402/7/23 |  |
| 116 | 1.4.4.2.1 | **63/20KV AVR Panel Schematic Diagram** | 16d | 2026-05-11 | 2026-05-26 |  | 2025-06-10 | 2025-10-24 | 137d | 0d | 27.54 | 1405/2/21 | 1405/3/5 | 16days | 1401/10/8 | 1402/6/5 | 1402/6/28 | 1402/4/19 | 1402/6/12 | C9 |
| 117 | 1.4.4.2.1.1 | 63/20KV AVR Panel Schematic Diagram-طراحي اوليه مدرك | 5d | 2026-05-11 | 2026-05-15 | 49, 64 |  |  |  | 0d |  | 1405/2/21 | 1405/2/25 | 5days |  |  |  |  |  |  |
| 118 | 1.4.4.2.1.2 | 63/20KV AVR Panel Schematic Diagram-بررسي مدرك توسط مشاور | 5d | 2026-05-16 | 2026-05-20 | 117 |  |  |  | 0d |  | 1405/2/26 | 1405/2/30 | 5days |  |  |  |  |  |  |
| 119 | 1.4.4.2.1.3 | 63/20KV AVR Panel Schematic Diagram-اصلاح مدرك | 3d | 2026-05-21 | 2026-05-23 | 118 |  |  |  | 0d |  | 1405/2/31 | 1405/3/2 | 3days |  |  |  |  |  |  |
| 120 | 1.4.4.2.1.4 | 63/20KV AVR Panel Schematic Diagram-تاييد مدرك توسط مشاور | 3d | 2026-05-24 | 2026-05-26 | 119 |  |  |  | 0d |  | 1405/3/3 | 1405/3/5 | 3days |  |  |  |  |  |  |
| 121 | 1.4.4.2.2 | **Load Shedding Protection Panel Schematic Diagram** | 16d | 2026-05-11 | 2026-05-26 |  | 2025-06-10 | 2025-10-24 | 137d | 0d | 27.54 | 1405/2/21 | 1405/3/5 | 16days | 1401/10/8 | 1402/6/5 | 1402/6/28 | 1402/4/19 | 1402/6/12 | C9 |
| 122 | 1.4.4.2.2.1 | Load Shedding Protection Panel Schematic Diagraml-طراحي اوليه مدرك | 5d | 2026-05-11 | 2026-05-15 | 49, 64 |  |  |  | 0d |  | 1405/2/21 | 1405/2/25 | 5days |  |  |  |  |  |  |
| 123 | 1.4.4.2.2.2 | Load Shedding Protection Panel Schematic Diagraml-بررسي مدرك توسط مشاور | 5d | 2026-05-16 | 2026-05-20 | 122 |  |  |  | 0d |  | 1405/2/26 | 1405/2/30 | 5days |  |  |  |  |  |  |
| 124 | 1.4.4.2.2.3 | Load Shedding Protection Panel Schematic Diagram-اصلاح مدرك | 3d | 2026-05-21 | 2026-05-23 | 123 |  |  |  | 0d |  | 1405/2/31 | 1405/3/2 | 3days |  |  |  |  |  |  |
| 125 | 1.4.4.2.2.4 | Load Shedding Protection Panel Schematic Diagraml-تاييد مدرك توسط مشاور | 3d | 2026-05-24 | 2026-05-26 | 124 |  |  |  | 0d |  | 1405/3/3 | 1405/3/5 | 3days |  |  |  |  |  |  |
| 126 | 1.4.4.2.3 | **63kV Incoming Control & Protection Panel Schematic Diagram** | 16d | 2026-05-11 | 2026-05-26 | 45, 60 | 2024-08-04 | 2025-11-02 | 456d | 0d | 27.54 | 1405/2/21 | 1405/3/5 | 16days | 1401/10/8 | 1402/6/5 | 1402/6/28 | 1402/4/26 | 1402/6/19 | C11 |
| 127 | 1.4.4.2.3.1 | 63kV Incoming Control & Protection Panel Schematic Diagram-طراحي اوليه مدرك | 5d | 2026-05-11 | 2026-05-15 | 49, 64 |  |  |  | 0d |  | 1405/2/21 | 1405/2/25 | 5days |  |  |  |  |  |  |
| 128 | 1.4.4.2.3.2 | 63kV Incoming Control & Protection Panel Schematic Diagram-بررسي مدرك توسط مشاور | 5d | 2026-05-16 | 2026-05-20 | 127 |  |  |  | 0d |  | 1405/2/26 | 1405/2/30 | 5days |  |  |  |  |  |  |
| 129 | 1.4.4.2.3.3 | 63kV Incoming Control & Protection Panel Schematic Diagram-اصلاح مدرك | 3d | 2026-05-21 | 2026-05-23 | 128 |  |  |  | 0d |  | 1405/2/31 | 1405/3/2 | 3days |  |  |  |  |  |  |
| 130 | 1.4.4.2.3.4 | 63kV Incoming Control & Protection Panel Schematic Diagram-تاييد مدرك توسط مشاور | 3d | 2026-05-24 | 2026-05-26 | 129 |  |  |  | 0d |  | 1405/3/3 | 1405/3/5 | 3days |  |  |  |  |  |  |

| ID | WBS | Task | Duration | Start | Finish | Predecessors | Baseline start | Baseline finish | Baseline duration | Total slack | Baseline cost | شروع | پایان | Duration. | Text4 | Text10 | Text11 | Text12 | Text13 | Text30 |
| --- | --- | --- | --- | --- | --- | --- | --- | --- | --- | --- | --- | --- | --- | --- | --- | --- | --- | --- | --- | --- |
| 131 | 1.4.4.2.4 | **20kV Outgoing Feeder Metering Panel Schematic Diagram** | 16d | 2026-05-11 | 2026-05-26 |  | 2025-06-10 | 2025-11-19 | 163d | 0d | 27.54 | 1405/2/21 | 1405/3/5 | 16days | 1401/10/8 | 1402/6/5 | 1402/6/28 | 1402/5/28 | 1402/7/21 | C5 |
| 132 | 1.4.4.2.4.1 | 20kV Outgoing Feeder Metering Panel Schematic Diagram-طراحي اوليه مدرك | 5d | 2026-05-11 | 2026-05-15 | 44 |  |  |  | 0d |  | 1405/2/21 | 1405/2/25 | 5days |  |  |  |  |  |  |
| 133 | 1.4.4.2.4.2 | 20kV Outgoing Feeder Metering Panel Schematic Diagram-بررسي مدرك توسط مشاور | 5d | 2026-05-16 | 2026-05-20 | 132 |  |  |  | 0d |  | 1405/2/26 | 1405/2/30 | 5days |  |  |  |  |  |  |
| 134 | 1.4.4.2.4.3 | 20kV Outgoing Feeder Metering Panel Schematic Diagram-اصلاح مدرك | 3d | 2026-05-21 | 2026-05-23 | 133 |  |  |  | 0d |  | 1405/2/31 | 1405/3/2 | 3days |  |  |  |  |  |  |
| 135 | 1.4.4.2.4.4 | 20kV Outgoing Feeder Metering Panel Schematic Diagram-تاييد مدرك توسط مشاور | 3d | 2026-05-24 | 2026-05-26 | 134 |  |  |  | 0d |  | 1405/3/3 | 1405/3/5 | 3days |  |  |  |  |  |  |
| 136 | 1.4.4.2.5 | **20kV Metering Feeder LV Compartment Schematic Diagram** | 16d | 2026-05-11 | 2026-05-26 |  | 2025-06-10 | 2025-10-25 | 138d | 0d | 27.54 | 1405/2/21 | 1405/3/5 | 16days | 1401/10/8 | 1402/6/5 | 1402/6/28 | 1402/5/28 | 1402/7/21 | C5 |
| 137 | 1.4.4.2.5.1 | 63/20KV AVR Panel Schematic Diagram-طراحي اوليه مدرك | 5d | 2026-05-11 | 2026-05-15 | 44 |  |  |  | 0d |  | 1405/2/21 | 1405/2/25 | 5days |  |  |  |  |  |  |
| 138 | 1.4.4.2.5.2 | 63/20KV AVR Panel Schematic Diagram-بررسي مدرك توسط مشاور | 5d | 2026-05-16 | 2026-05-20 | 137 |  |  |  | 0d |  | 1405/2/26 | 1405/2/30 | 5days |  |  |  |  |  |  |
| 139 | 1.4.4.2.5.3 | 63/20KV AVR Panel Schematic Diagram-اصلاح مدرك | 3d | 2026-05-21 | 2026-05-23 | 138 |  |  |  | 0d |  | 1405/2/31 | 1405/3/2 | 3days |  |  |  |  |  |  |
| 140 | 1.4.4.2.5.4 | 63/20KV AVR Panel Schematic Diagram-تاييد مدرك توسط مشاور | 3d | 2026-05-24 | 2026-05-26 | 139 |  |  |  | 0d |  | 1405/3/3 | 1405/3/5 | 3days |  |  |  |  |  |  |
| 141 | 1.4.4.2.6 | **LVAC Panel Schematic Diagram** | 16d | 2026-05-11 | 2026-05-26 | 45, 60 | 2025-06-10 | 2025-11-08 | 152d | 0d | 27.54 | 1405/2/21 | 1405/3/5 | 16days | 1401/10/8 | 1402/6/5 | 1402/6/28 | 1402/5/23 | 1402/7/14 | C4 |
| 142 | 1.4.4.2.6.1 | LVAC Panel Schematic Diagram.-طراحي اوليه مدرك | 5d | 2026-05-11 | 2026-05-15 | 94 |  |  |  | 0d |  | 1405/2/21 | 1405/2/25 | 5days |  |  |  |  |  |  |
| 143 | 1.4.4.2.6.2 | LVAC Panel Schematic Diagram-بررسي مدرك توسط مشاور | 5d | 2026-05-16 | 2026-05-20 | 142 |  |  |  | 0d |  | 1405/2/26 | 1405/2/30 | 5days |  |  |  |  |  |  |
| 144 | 1.4.4.2.6.3 | LVAC Panel Schematic Diagram-اصلاح مدرك | 3d | 2026-05-21 | 2026-05-23 | 143 |  |  |  | 0d |  | 1405/2/31 | 1405/3/2 | 3days |  |  |  |  |  |  |
| 145 | 1.4.4.2.6.4 | LVAC Panel Schematic Diagram-تاييد مدرك توسط مشاور | 3d | 2026-05-24 | 2026-05-26 | 144 |  |  |  | 0d |  | 1405/3/3 | 1405/3/5 | 3days |  |  |  |  |  |  |
| 146 | 1.4.4.2.7 | **LVDC Panel Schematic Diagram** | 16d | 2026-05-11 | 2026-05-26 |  | 2025-06-10 | 2025-11-10 | 153.5d | 0d | 27.54 | 1405/2/21 | 1405/3/5 | 16days | 1401/10/8 | 1402/6/5 | 1402/6/28 | 1402/5/30 | 1402/7/23 | C9 |
| 147 | 1.4.4.2.7.1 | LVDC Panel Schematic Diagram-طراحي اوليه مدرك | 5d | 2026-05-11 | 2026-05-15 | 104 |  |  |  | 0d |  | 1405/2/21 | 1405/2/25 | 5days |  |  |  |  |  |  |
| 148 | 1.4.4.2.7.2 | LVDC Panel Schematic Diagram-بررسي مدرك توسط مشاور | 5d | 2026-05-16 | 2026-05-20 | 147 |  |  |  | 0d |  | 1405/2/26 | 1405/2/30 | 5days |  |  |  |  |  |  |
| 149 | 1.4.4.2.7.3 | LVDC Panel Schematic Diagram--اصلاح مدرك | 3d | 2026-05-21 | 2026-05-23 | 148 |  |  |  | 0d |  | 1405/2/31 | 1405/3/2 | 3days |  |  |  |  |  |  |
| 150 | 1.4.4.2.7.4 | LVDC Panel Schematic Diagram--تاييد مدرك توسط مشاور | 3d | 2026-05-24 | 2026-05-26 | 149 |  |  |  | 0d |  | 1405/3/3 | 1405/3/5 | 3days |  |  |  |  |  |  |
| 151 | 1.4.4.2.8 | **48VDC Panel Schematic Diagram** | 16d | 2026-05-11 | 2026-05-26 |  | 2025-06-10 | 2025-11-10 | 153.5d | 0d | 27.54 | 1405/2/21 | 1405/3/5 | 16days | 1401/10/8 | 1402/6/5 | 1402/6/28 | 1402/5/30 | 1402/7/23 | C12 |
| 152 | 1.4.4.2.8.1 | 48VDC Panel Schematic Diagram-طراحي اوليه مدرك | 5d | 2026-05-11 | 2026-05-15 | 109 |  |  |  | 0d |  | 1405/2/21 | 1405/2/25 | 5days |  |  |  |  |  |  |
| 153 | 1.4.4.2.8.2 | 48VDC Panel Schematic Diagram-بررسي مدرك توسط مشاور | 5d | 2026-05-16 | 2026-05-20 | 152 |  |  |  | 0d |  | 1405/2/26 | 1405/2/30 | 5days |  |  |  |  |  |  |
| 154 | 1.4.4.2.8.3 | 48VDC Panel Schematic Diagram-اصلاح مدرك | 3d | 2026-05-21 | 2026-05-23 | 153 |  |  |  | 0d |  | 1405/2/31 | 1405/3/2 | 3days |  |  |  |  |  |  |
| 155 | 1.4.4.2.8.4 | 48VDC Panel Schematic Diagram-تاييد مدرك توسط مشاور | 3d | 2026-05-24 | 2026-05-26 | 154 |  |  |  | 0d |  | 1405/3/3 | 1405/3/5 | 3days |  |  |  |  |  |  |

| ID | WBS | Task | Duration | Start | Finish | Predecessors | Complete | Remaining | Baseline start | Baseline finish | Baseline duration | Total slack | Constraint | Cost | Baseline cost | شروع | پایان | Duration. | Text4 | Text10 | Text11 | Text12 | Text13 | Text30 |
| --- | --- | --- | --- | --- | --- | --- | --- | --- | --- | --- | --- | --- | --- | --- | --- | --- | --- | --- | --- | --- | --- | --- | --- | --- |
| 156 | 1.4.4.2.9 | **Measuring Panel Schematic Diagram** | 16d | 2026-05-11 | 2026-05-26 |  |  |  | 2025-06-10 | 2025-11-19 | 162.5d | 0d |  |  | 27.54 | 1405/2/21 | 1405/3/5 | 16days | 1401/10/8 | 1402/6/5 | 1402/6/28 | 1402/6/6 | 1402/7/14 | C26 |
| 157 | 1.4.4.2.9.1 | Measuring Panel Schematic Diagram-طراحي اوليه مدرك | 5d | 2026-05-11 | 2026-05-15 | 49, 64, 114 |  |  |  |  |  | 0d |  |  |  | 1405/2/21 | 1405/2/25 | 5days |  |  |  |  |  |  |
| 158 | 1.4.4.2.9.2 | Measuring Panel Schematic Diagram-بررسي مدرك توسط مشاور | 5d | 2026-05-16 | 2026-05-20 | 157 |  |  |  |  |  | 0d |  |  |  | 1405/2/26 | 1405/2/30 | 5days |  |  |  |  |  |  |
| 159 | 1.4.4.2.9.3 | Measuring Panel Schematic Diagram-اصلاح مدرك | 3d | 2026-05-21 | 2026-05-23 | 158 |  |  |  |  |  | 0d |  |  |  | 1405/2/31 | 1405/3/2 | 3days |  |  |  |  |  |  |
| 160 | 1.4.4.2.9.4 | Measuring Panel Schematic Diagram-تاييد مدرك توسط مشاور | 3d | 2026-05-24 | 2026-05-26 | 159 |  |  |  |  |  | 0d |  |  |  | 1405/3/3 | 1405/3/5 | 3days |  |  |  |  |  |  |
| 161 | 1.4.4.3 | **سفارش ها و مشخصات فنی** | 25d | 2026-05-27 | 2026-06-20 |  |  |  | 2023-04-09 | 2025-11-20 | 941.5d | 0d |  |  | 330.48 | 1405/3/6 | 1405/3/30 | 25days | 1401/10/22 | 1402/1/20 | 1402/6/31 | 1402/1/25 | 1402/8/17 |  |
| 162 | 1.4.4.3.1 | **Protection Relay Ordering** | 25d | 2026-05-27 | 2026-06-20 |  |  |  | 2023-04-09 | 2023-05-04 | 26d | 0d |  |  | 27.54 | 1405/3/6 | 1405/3/30 | 25days | 1401/8/29 | 1402/1/20 | 1402/2/14 | 1402/1/25 | 1402/2/19 | D1 |
| 163 | 1.4.4.3.1.1 | Protection Relay Ordering-طراحي اوليه مدرك | 10d | 2026-05-27 | 2026-06-05 | 160, 44 |  |  |  |  |  | 0d |  |  |  | 1405/3/6 | 1405/3/15 | 10days |  |  |  |  |  |  |
| 164 | 1.4.4.3.1.2 | Protection Relay Ordering-بررسي مدرك توسط مشاور | 5d | 2026-06-06 | 2026-06-10 | 163 |  |  |  |  |  | 0d |  |  |  | 1405/3/16 | 1405/3/20 | 5days |  |  |  |  |  |  |
| 165 | 1.4.4.3.1.3 | Protection Relay Ordering-اصلاح مدرك | 5d | 2026-06-11 | 2026-06-15 | 164 |  |  |  |  |  | 0d |  |  |  | 1405/3/21 | 1405/3/25 | 5days |  |  |  |  |  |  |
| 166 | 1.4.4.3.1.4 | Protection Relay Ordering-تاييد مدرك توسط مشاور | 5d | 2026-06-16 | 2026-06-20 | 165 |  |  |  |  |  | 0d |  |  |  | 1405/3/26 | 1405/3/30 | 5days |  |  |  |  |  |  |
| 167 | 1.4.4.3.2 | **Protection Relay, Control & Communication Equipment Technical Specification** | 25d | 2026-05-27 | 2026-06-20 | 40, 45 |  |  | 2023-04-28 | 2025-06-29 | 779d | 0d |  |  | 27.54 | 1405/3/6 | 1405/3/30 | 25days | 1401/10/22 | 1402/2/8 | 1402/3/3 | 1402/2/13 | 1402/3/8 |  |
| 168 | 1.4.4.3.2.1 | Protection Relay, Control & Communication Equipment Tec. Spec-طراحي اوليه مدرك | 10d | 2026-05-27 | 2026-06-05 | 49, 64, 160 |  |  |  |  |  | 0d |  |  |  | 1405/3/6 | 1405/3/15 | 10days |  |  |  |  |  |  |
| 169 | 1.4.4.3.2.2 | Protection Relay, Control & Communication Equipment Tec. Spec-بررسي مدرك توسط مشاور | 5d | 2026-06-06 | 2026-06-10 | 168 |  |  |  |  |  | 0d |  |  |  | 1405/3/16 | 1405/3/20 | 5days |  |  |  |  |  |  |
| 170 | 1.4.4.3.2.3 | Protection Relay, Control & Communication Equipment Tec. Spec-اصلاح مدرك | 5d | 2026-06-11 | 2026-06-15 | 169 |  |  |  |  |  | 0d |  |  |  | 1405/3/21 | 1405/3/25 | 5days |  |  |  |  |  |  |
| 171 | 1.4.4.3.2.4 | Protection Relay, Control & Communication Equipment Tec. Spec-تاييد مدرك توسط مشاور | 5d | 2026-06-16 | 2026-06-20 | 170 |  |  |  |  |  | 0d |  |  |  | 1405/3/26 | 1405/3/30 | 5days |  |  |  |  |  |  |
| 172 | 1.4.5 | **ساختمانی** | 21d | 2026-04-25 | 2026-05-15 |  |  |  | 2023-01-14 | 2025-11-17 | 1024d | 0d |  |  | 1,321.92 | 1405/2/5 | 1405/2/25 | 21days | 1401/10/10 | 1401/10/24 | 1402/6/31 | 1401/12/7 | 1402/7/11 |  |
| 173 | 1.4.5.1 | **مدارک پایه** | 21d | 2026-04-25 | 2026-05-15 |  |  |  | 2023-02-25 | 2023-02-25 | 0d | 0d |  |  | 27.54 | 1405/2/5 | 1405/2/25 | 21days |  | 1401/12/6 | 1401/12/6 | 1401/12/7 | 1402/1/10 |  |
| 174 | 1.4.5.1.1 | **EARTH WORKING PLAN** | 21d | 2026-04-25 | 2026-05-15 |  |  |  | 2023-02-25 | 2023-02-25 | 0d | 0d |  |  | 27.54 | 1405/2/5 | 1405/2/25 | 21days |  | 1401/12/6 | 1401/12/6 | 1401/12/7 | 1402/1/10 |  |
| 175 | 1.4.5.1.1.1 | EARTH WORKING PLAN-طراحي اوليه مدرك | 6d | 2026-04-25 | 2026-04-30 | 7FS+55d |  |  |  |  |  | 0d |  |  |  | 1405/2/5 | 1405/2/10 | 6days |  |  |  |  |  |  |
| 176 | 1.4.5.1.1.2 | EARTH WORKING PLAN-بررسي مدرك توسط مشاور | 5d | 2026-05-01 | 2026-05-05 | 175 |  |  |  |  |  | 0d |  |  |  | 1405/2/11 | 1405/2/15 | 5days |  |  |  |  |  |  |
| 177 | 1.4.5.1.1.3 | EARTH WORKING PLAN-اصلاح مدرك | 5d | 2026-05-06 | 2026-05-10 | 176 |  |  |  |  |  | 0d |  |  |  | 1405/2/16 | 1405/2/20 | 5days |  |  |  |  |  |  |
| 178 | 1.4.5.1.1.4 | EARTH WORKING PLAN-تاييد مدرك توسط مشاور | 5d | 2026-05-11 | 2026-05-15 | 177 |  |  |  |  |  | 0d |  |  |  | 1405/2/21 | 1405/2/25 | 5days |  |  |  |  |  |  |
| 179 | 1.5 | **تامین تجهیزات** | 106d | 2026-05-10 A | 2026-08-23 |  | 3% | 103.23d | 2023-05-21 | 2026-01-19 | 960d | 0d |  | 21,557 | 694,146.5 | 1405/2/20 | 1405/6/1 | 106days | 1402/2/16 | 1402/2/31 | 1402/12/23 | 1402/2/20 | 1403/1/22 |  |
| 180 | 1.5.1 | **بخش فشار قوی** | 95d | 2026-05-10 A | 2026-08-12 |  | 6% | 89.53d | 2023-05-21 | 2026-01-19 | 960d | 0d |  | 21,557 | 406,058.5 | 1405/2/20 | 1405/5/21 | 95days |  | 1402/2/31 | 1402/12/15 | 1402/5/4 | 1403/1/22 |  |
| 181 | 1.5.1.1 | **تابلو های فشار متوسط** | 95d | 2026-05-10 A | 2026-08-12 |  | 8% | 87d | 2023-09-20 | 2026-01-19 | 838d | 0d |  | 21,557 | 21,557 | 1405/2/20 | 1405/5/21 | 95days | 1402/1/5 | 1402/6/29 | 1402/10/21 | 1402/5/6 | 1402/12/25 |  |
| 182 | 1.5.1.1.1 | استعلام و دریافت پیشنهاد سازندگان | 3d | 2026-05-10 A | 2026-05-12 A | 32 | 100% |  | 2023-09-20 | 2023-09-22 | 3d |  |  |  |  | 1405/2/20 | 1405/2/22 | 3days | 1401/10/22 | 1402/6/29 | 1402/6/31 | 1402/5/6 | 1402/5/19 |  |
| 183 | 1.5.1.1.2 | انتخاب نهایی سازنده و ثبت سفارش | 5d | 2026-05-13 A | 2026-05-17 A | 182 | 100% |  | 2023-09-23 | 2025-06-28 | 25.79d |  |  |  |  | 1405/2/23 | 1405/2/27 | 5days | 1401/10/25 | 1402/7/1 | 1402/7/7 | 1402/5/20 | 1402/5/29 |  |
| 184 | 1.5.1.1.3 | پرداخت پیش پرداخت | 7d | 2026-05-18 | 2026-05-24 | 183 |  |  | 2025-10-05 | 2025-10-11 | 7d | 0d | start no earlier than 2026-03-17 |  |  | 1405/2/28 | 1405/3/3 | 7days | 1401/10/26 | 1402/7/8 | 1402/7/14 | 1402/5/30 | 1402/6/12 |  |
| 185 | 1.5.1.1.4 | ساخت | 60d | 2026-05-25 | 2026-07-23 | 184 |  |  | 2025-10-12 | 2025-12-30 | 80d | 0d | start no earlier than 2026-03-29 |  |  | 1405/3/4 | 1405/5/1 | 60days | 1401/12/29 | 1402/7/20 | 1402/10/9 | 1402/6/23 | 1402/12/2 |  |
| 186 | 1.5.1.1.5 | تست کارخانه ای | 5d | 2026-07-24 | 2026-07-28 | 185 |  |  | 2025-12-31 | 2026-01-04 | 5d | 0d | start no earlier than 2025-02-22 | 4,311 | 4,311 | 1405/5/2 | 1405/5/6 | 5days | 1402/1/2 | 1402/10/10 | 1402/10/12 | 1402/12/3 | 1402/12/7 |  |
| 187 | 1.5.1.1.6 | دریافت تست شیت | 5d | 2026-07-29 | 2026-08-02 | 186 |  |  | 2026-01-05 | 2026-01-09 | 5d | 0d | start no earlier than 2025-02-22 |  |  | 1405/5/7 | 1405/5/11 | 5days | 1401/11/8 | 1402/10/13 | 1402/10/14 | 1402/12/8 | 1402/12/9 |  |
| 188 | 1.5.1.1.7 | آخرین پرداخت به سازنده | 5d | 2026-08-03 | 2026-08-07 | 186, 187 |  |  | 2026-01-10 | 2026-01-14 | 5d | 0d | start no earlier than 2025-02-22 |  |  | 1405/5/12 | 1405/5/16 | 5days | 1402/1/3 | 1402/10/15 | 1402/10/16 | 1402/12/10 | 1402/12/11 |  |
| 189 | 1.5.1.1.8 | حمل و تحویل-تابلو های فشار متوسط | 5d | 2026-08-08 | 2026-08-12 | 188 |  |  | 2026-01-15 | 2026-01-19 | 5d | 0d | start no earlier than 2025-02-22 | 17,246 | 17,246 | 1405/5/17 | 1405/5/21 | 5days | 1402/1/5 | 1402/10/17 | 1402/10/21 | 1402/12/12 | 1402/12/25 |  |

| ID | WBS | Task | Duration | Start | Finish | Predecessors | Baseline start | Baseline finish | Baseline duration | Total slack | Baseline cost | شروع | پایان | Duration. | Text4 | Text10 | Text11 | Text12 | Text13 |
| --- | --- | --- | --- | --- | --- | --- | --- | --- | --- | --- | --- | --- | --- | --- | --- | --- | --- | --- | --- |
| 190 | 1.5.1.2 | **تجهیزات سیستم زمین** | 44d | 2026-05-21 | 2026-07-03 |  | 2023-09-07 | 2026-01-05 | 837d | 0d | 64,556 | 1405/2/31 | 1405/4/12 | 44days | 1401/11/12 | 1402/6/16 | 1402/9/13 | 1402/6/7 | 1402/8/28 |
| 191 | 1.5.1.2.1 | استعلام و دریافت پیشنهاد سازندگان | 2d | 2026-05-21 | 2026-05-22 | 37 |  |  |  | 0d |  | 1405/2/31 | 1405/3/1 | 2days |  |  |  |  |  |
| 192 | 1.5.1.2.2 | انتخاب نهایی سازنده و ثبت سفارش | 2d | 2026-05-23 | 2026-05-24 | 191 |  |  |  | 0d |  | 1405/3/2 | 1405/3/3 | 2days |  |  |  |  |  |
| 193 | 1.5.1.2.3 | پرداخت پیش پرداخت | 7d | 2026-05-25 | 2026-05-31 | 192 |  |  |  | 0d |  | 1405/3/4 | 1405/3/10 | 7days |  |  |  |  |  |
| 194 | 1.5.1.2.4 | ساخت | 7d | 2026-06-01 | 2026-06-07 | 193 |  |  |  | 0d |  | 1405/3/11 | 1405/3/17 | 7days |  |  |  |  |  |
| 195 | 1.5.1.2.5 | تست کارخانه ای | 5d | 2026-06-08 | 2026-06-12 | 194 |  |  |  | 0d |  | 1405/3/18 | 1405/3/22 | 5days |  |  |  |  |  |
| 196 | 1.5.1.2.6 | دریافت تست شیت | 7d | 2026-06-13 | 2026-06-19 | 195 |  |  |  | 0d |  | 1405/3/23 | 1405/3/29 | 7days |  |  |  |  |  |
| 197 | 1.5.1.2.7 | آخرین پرداخت به سازنده | 7d | 2026-06-20 | 2026-06-26 | 196 |  |  |  | 0d |  | 1405/3/30 | 1405/4/5 | 7days |  |  |  |  |  |
| 198 | 1.5.1.2.8 | حمل و تحویل-تجهیزات سیستم زمین | 7d | 2026-06-27 | 2026-07-03 | 197 |  |  |  | 0d |  | 1405/4/6 | 1405/4/12 | 7days |  |  |  |  |  |
| 199 | 1.5.2 | **بخش فشار ضعیف** | 89d | 2026-05-27 | 2026-08-23 |  | 2023-07-23 | 2026-01-19 | 897d | 0d | 288,088 | 1405/3/6 | 1405/6/1 | 89days |  | 1402/5/1 | 1402/12/23 | 1402/2/20 | 1403/1/14 |
| 200 | 1.5.2.1 | **بدنه و ملحقات داخلی تابلو های حفاظت و کنترل** | 89d | 2026-05-27 | 2026-08-23 |  | 2023-10-14 | 2026-01-13 | 808d | 0d | 24,819 | 1405/3/6 | 1405/6/1 | 89days | 1401/12/14 | 1402/7/22 | 1402/12/23 | 1402/7/21 | 1402/12/24 |
| 201 | 1.5.2.1.1 | استعلام و دریافت پیشنهاد سازندگان | 3d | 2026-05-27 | 2026-05-29 | 145, 150 |  |  |  | 0d |  | 1405/3/6 | 1405/3/8 | 3days |  |  |  |  |  |
| 202 | 1.5.2.1.2 | انتخاب نهایی سازنده و ثبت سفارش | 5d | 2026-05-30 | 2026-06-03 | 201 |  |  |  | 0d |  | 1405/3/9 | 1405/3/13 | 5days |  |  |  |  |  |
| 203 | 1.5.2.1.3 | پرداخت پیش پرداخت | 3d | 2026-06-04 | 2026-06-06 | 202 |  |  |  | 0d |  | 1405/3/14 | 1405/3/16 | 3days |  |  |  |  |  |
| 204 | 1.5.2.1.4 | ساخت | 60d | 2026-06-07 | 2026-08-05 | 203 |  |  |  | 0d |  | 1405/3/17 | 1405/5/14 | 60days |  |  |  |  |  |
| 205 | 1.5.2.1.5 | تست کارخانه ای | 4d | 2026-08-06 | 2026-08-09 | 204 |  |  |  | 0d |  | 1405/5/15 | 1405/5/18 | 4days |  |  |  |  |  |
| 206 | 1.5.2.1.6 | دریافت تست شیت | 4d | 2026-08-10 | 2026-08-13 | 205 |  |  |  | 0d |  | 1405/5/19 | 1405/5/22 | 4days |  |  |  |  |  |
| 207 | 1.5.2.1.7 | آخرین پرداخت به سازنده | 5d | 2026-08-14 | 2026-08-18 | 206 |  |  |  | 0d |  | 1405/5/23 | 1405/5/27 | 5days |  |  |  |  |  |
| 208 | 1.5.2.1.8 | حمل و تحویل- بدنه و ملحقات داخلی تابلو های حفاظت و کنترل | 5d | 2026-08-19 | 2026-08-23 | 207 |  |  |  | 0d |  | 1405/5/28 | 1405/6/1 | 5days |  |  |  |  |  |
| 209 | 1.5.2.2 | **AC/DC بدنه و ملحقات داخلی تابلو های** | 78d | 2026-05-27 | 2026-08-12 |  | 2023-10-23 | 2026-01-08 | 794d | 0d | 12,074 | 1405/3/6 | 1405/5/21 | 78days | 1401/12/29 | 1402/8/1 | 1402/11/27 | 1402/8/2 | 1402/12/11 |
| 210 | 1.5.2.2.1 | استعلام و دریافت پیشنهاد سازندگان | 7d | 2026-05-27 | 2026-06-02 | 155 |  |  |  | 0d |  | 1405/3/6 | 1405/3/12 | 7days |  |  |  |  |  |
| 211 | 1.5.2.2.2 | انتخاب نهایی سازنده و ثبت سفارش | 5d | 2026-06-03 | 2026-06-07 | 210 |  |  |  | 0d |  | 1405/3/13 | 1405/3/17 | 5days |  |  |  |  |  |
| 212 | 1.5.2.2.3 | پرداخت پیش پرداخت | 7d | 2026-06-08 | 2026-06-14 | 211 |  |  |  | 0d |  | 1405/3/18 | 1405/3/24 | 7days |  |  |  |  |  |
| 213 | 1.5.2.2.4 | ساخت | 40d | 2026-06-15 | 2026-07-24 | 212 |  |  |  | 0d |  | 1405/3/25 | 1405/5/2 | 40days |  |  |  |  |  |
| 214 | 1.5.2.2.5 | تست کارخانه ای | 5d | 2026-07-25 | 2026-07-29 | 213 |  |  |  | 0d |  | 1405/5/3 | 1405/5/7 | 5days |  |  |  |  |  |
| 215 | 1.5.2.2.6 | دریافت تست شیت | 4d | 2026-07-30 | 2026-08-02 | 214 |  |  |  | 0d |  | 1405/5/8 | 1405/5/11 | 4days |  |  |  |  |  |
| 216 | 1.5.2.2.7 | آخرین پرداخت به سازنده | 5d | 2026-08-03 | 2026-08-07 | 215 |  |  |  | 0d |  | 1405/5/12 | 1405/5/16 | 5days |  |  |  |  |  |
| 217 | 1.5.2.2.8 | حمل و تحویل-AC/DC بدنه و ملحقات داخلی تابلو های | 5d | 2026-08-08 | 2026-08-12 | 216 |  |  |  | 0d |  | 1405/5/17 | 1405/5/21 | 5days |  |  |  |  |  |

| ID | WBS | Task | Duration | Start | Finish | Predecessors | Baseline start | Baseline finish | Baseline duration | Total slack | Cost | Baseline cost | شروع | پایان | Duration. | Text4 | Text10 | Text11 | Text12 | Text13 |
| --- | --- | --- | --- | --- | --- | --- | --- | --- | --- | --- | --- | --- | --- | --- | --- | --- | --- | --- | --- | --- |
| 218 | 1.6 | **اجرا** | 133d | 2026-04-28 | 2026-09-07 |  | 2023-02-28 | 2026-03-20 | 1102d | 0d | 22,820 | 403,558 | 1405/2/8 | 1405/6/16 | 133days | 1402/3/21 | 1401/12/9 | 1403/4/23 | 1401/12/15 | 1403/5/3 |
| 219 | 1.6.1 | **اجرای ساختمانی** | 96d | 2026-04-28 | 2026-08-01 |  | 2023-02-28 | 2026-03-05 | 1087d | 0d |  | 356,994 | 1405/2/8 | 1405/5/10 | 96days | 1402/3/14 | 1402/2/24 | 1403/4/9 | 1401/12/15 | 1403/4/18 |
| 220 | 1.6.1.1 | **تجهیز کارگاه** | 40d | 2026-04-28 | 2026-06-06 |  | 2023-02-28 | 2026-02-20 | 1073.48d | 0d |  | 11,187 | 1405/2/8 | 1405/3/16 | 40days |  | 1401/12/9 | 1403/4/23 | 1401/12/15 | 1403/4/18 |
| 221 | 1.6.1.1.1 | تجهیزکارگاه-اولیه | 40d | 2026-04-28 | 2026-06-06 | 4 |  |  |  | 0d |  |  | 1405/2/8 | 1405/3/16 | 40days |  |  |  |  |  |
| 222 | 1.6.1.2 | **بخش 63 کیلوولت** | 70d | 2026-05-24 | 2026-08-01 |  | 2023-05-14 | 2026-03-05 | 1012d | 0d |  | 345,807 | 1405/3/3 | 1405/5/10 | 70days |  |  |  |  |  |
| 223 | 1.6.1.2.1 | **اجراي خاكبرداري و خاكريزي** | 39d | 2026-05-24 | 2026-07-01 |  | 2023-05-14 | 2023-08-12 | 91d | 0d |  | 10,377 | 1405/3/3 | 1405/4/10 | 39days | 1401/9/26 | 1402/2/28 | 1402/5/21 | 1402/1/28 | 1402/2/14 |
| 224 | 1.6.1.2.1.1 | پياده كردن نقشه هاي عمليات خاكي | 5d | 2026-05-24 | 2026-05-28 | 221FS-14d |  |  |  | 0d |  |  | 1405/3/3 | 1405/3/7 | 5days |  |  |  |  |  |
| 225 | 1.6.1.2.1.2 | عمليات خاكي -خاكبرداري - ناحيه تجهيز كارگاه | 5d | 2026-05-29 | 2026-06-02 | 224 |  |  |  | 0d |  |  | 1405/3/8 | 1405/3/12 | 5days |  |  |  |  |  |
| 226 | 1.6.1.2.1.3 | عمليات خاكي -خاکریزی - ناحيه تجهيز كارگاه | 5d | 2026-06-03 | 2026-06-07 | 225 |  |  |  | 0d |  |  | 1405/3/13 | 1405/3/17 | 5days |  |  |  |  |  |
| 227 | 1.6.1.2.1.4 | عمليات خاكي -خاكبرداري - ناحيه 63 كيلوولت | 12d | 2026-06-08 | 2026-06-19 | 226 |  |  |  | 0d |  |  | 1405/3/18 | 1405/3/29 | 12days |  |  |  |  |  |
| 228 | 1.6.1.2.1.5 | عمليات خاكي -خاكبرداري - ناحيه ساختمان كنترل | 5d | 2026-06-20 | 2026-06-24 | 227 |  |  |  | 0d |  |  | 1405/3/30 | 1405/4/3 | 5days |  |  |  |  |  |
| 229 | 1.6.1.2.1.6 | عمليات خاكي -خاكبرداري - ناحيه پاركينگ - ديزل - نگهباني | 7d | 2026-06-25 | 2026-07-01 | 228 |  |  |  | 0d |  |  | 1405/4/4 | 1405/4/10 | 7days |  |  |  |  |  |
| 230 | 1.6.1.2.2 | **اجراي فونداسيون تجهيزات بخش 63 کیلوولت** | 50d | 2026-05-24 | 2026-07-12 |  | 2023-07-02 | 2025-12-11 | 879d | 0d |  | 79,560 | 1405/3/3 | 1405/4/21 | 50days | 1401/11/24 | 1402/4/11 | 1402/8/9 | 1402/4/25 | 1402/7/15 |
| 231 | 1.6.1.2.2.1 | **فونداسیون تجهیزات و ترانس ها** | 50d | 2026-05-24 | 2026-07-12 |  | 2023-07-02 | 2024-07-18 | 367.55d | 0d |  | 39,780 | 1405/3/3 | 1405/4/21 | 50days | 1401/11/24 | 1402/4/11 | 1402/8/9 | 1402/4/25 | 1402/7/15 |
| 232 | 1.6.1.2.2.1.1 | پي كني ، تسطيح و لولينگ | 10d | 2026-05-24 | 2026-06-02 | 221FS-14d |  |  |  | 0d |  |  | 1405/3/3 | 1405/3/12 | 10days |  |  |  |  |  |
| 233 | 1.6.1.2.2.1.2 | اجراي بتن مگر | 10d | 2026-06-03 | 2026-06-12 | 232 |  |  |  | 0d |  |  | 1405/3/13 | 1405/3/22 | 10days |  |  |  |  |  |
| 234 | 1.6.1.2.2.1.3 | آرماتور بندی پد | 10d | 2026-06-13 | 2026-06-22 | 233 |  |  |  | 0d |  |  | 1405/3/23 | 1405/4/1 | 10days |  |  |  |  |  |
| 235 | 1.6.1.2.2.1.4 | قالب بندی پد | 10d | 2026-06-23 | 2026-07-02 | 234 |  |  |  | 0d |  |  | 1405/4/2 | 1405/4/11 | 10days |  |  |  |  |  |
| 236 | 1.6.1.2.2.1.5 | بتن ريزی پد | 10d | 2026-07-03 | 2026-07-12 | 235 |  |  |  | 0d |  |  | 1405/4/12 | 1405/4/21 | 10days |  |  |  |  |  |
| 237 | 1.6.1.2.3 | شن ريزي محوطه | 20d | 2026-07-13 | 2026-08-01 | 231 |  |  |  | 0d |  |  | 1405/4/22 | 1405/5/10 | 20days |  |  |  |  |  |
| 238 | 1.6.2 | **اجرای برقی** | 30d | 2026-07-13 | 2026-08-11 |  | 2025-11-22 | 2026-02-28 | 98.3d | 0d |  | 22,543 | 1405/4/22 | 1405/5/20 | 30days | 1402/2/19 | 1402/9/26 | 1403/3/9 | 1402/10/9 | 1403/3/9 |
| 239 | 1.6.2.1 | **نصب تجهیزات محوطه بخش فیدر63 کیلوولت و فشارضعیف** | 14d | 2026-07-13 | 2026-07-26 |  | 2025-12-06 | 2026-02-12 | 68.3d | 0d |  | 5,636 | 1405/4/22 | 1405/5/4 | 14days | 1402/2/19 | 1402/11/19 | 1403/1/19 | 1402/12/18 | 1403/1/18 |
| 240 | 1.6.2.1.1 | نصب بی سیار 63 کیلوولت | 7d | 2026-07-13 | 2026-07-19 | 236 |  |  |  | 0d |  |  | 1405/4/22 | 1405/4/28 | 7days |  |  |  |  |  |
| 241 | 1.6.2.1.2 | نصب تابلوهای فشار متوسط و ضعیف و سیم کشی بین تجهیزات | 7d | 2026-07-20 | 2026-07-26 | 240 |  |  |  | 0d |  |  | 1405/4/29 | 1405/5/4 | 7days |  |  |  |  |  |

| ID | WBS | Task | Type | Duration | Start | Finish | Predecessors | Baseline start | Baseline finish | Baseline duration | Total slack | Free slack | Constraint | Cost | Baseline cost | شروع | پایان | Duration. | Text4 | Text10 | Text11 | Text12 | Text13 |
| --- | --- | --- | --- | --- | --- | --- | --- | --- | --- | --- | --- | --- | --- | --- | --- | --- | --- | --- | --- | --- | --- | --- | --- |
| 242 | 1.6.2.2 | **نصب سینی کابل** |  | 30d | 2026-07-13 | 2026-08-11 |  | 2026-01-07 | 2026-02-05 | 30d | 0d |  |  |  | 1,127 | 1405/4/22 | 1405/5/20 | 30days | 1402/1/20 | 1402/12/5 | 1403/1/21 | 1402/11/26 | 1403/1/30 |
| 243 | 1.6.2.2.1 | نصب سینی کابل محوطه |  | 10d | 2026-07-13 | 2026-07-22 | 236 |  |  |  | 0d |  |  |  |  | 1405/4/22 | 1405/4/31 | 10days |  |  |  |  |  |
| 244 | 1.6.2.2.2 | لوله گذاري بين تجهيزات و سيني كابل ها |  | 10d | 2026-07-23 | 2026-08-01 | 243 |  |  |  | 0d |  |  |  |  | 1405/5/1 | 1405/5/10 | 10days |  |  |  |  |  |
| 245 | 1.6.2.2.3 | نصب سيني كابل هاي ساختمان كنترل |  | 10d | 2026-08-02 | 2026-08-11 | 244 |  |  |  | 0d |  |  |  |  | 1405/5/11 | 1405/5/20 | 10days |  |  |  |  |  |
| 246 | 1.6.2.3 | نصب و راه اندازی سیستم مخابراتی |  | 15d | 2026-07-23 | 2026-08-06 | 245FS-20d |  |  |  | 0d |  |  |  |  | 1405/5/1 | 1405/5/15 | 15days |  |  |  |  |  |
| 247 | 1.6.3 | **تست و راه اندازی** |  | 63d | 2026-07-07 | 2026-09-07 |  | 2026-01-21 | 2026-03-20 | 59d | 0d |  |  | 22,820 | 24,021 | 1405/4/16 | 1405/6/16 | 63days | 1402/3/21 | 1403/2/9 | 1403/4/23 | 1403/1/23 | 1403/5/3 |
| 248 | 1.6.3.1 | تجهیزات محوطه |  | 10d | 2026-07-07 | 2026-07-16 | 239FS-20d | 2026-01-21 | 2026-02-19 | 30d | 0d |  | start no earlier than 2024-07-13 | 3,603 | 3,603 | 1405/4/16 | 1405/4/25 | 10days | 1402/2/26 | 1403/2/9 | 1403/2/22 | 1403/1/23 | 1403/2/5 |
| 249 | 1.6.3.2 | سیستم زمین |  | 10d | 2026-07-07 | 2026-07-16 | 239FS-20d | 2026-02-22 | 2026-03-03 | 10d | 51d |  | start no earlier than 2026-07-02 | 1,201 | 1,201 | 1405/4/16 | 1405/4/25 | 10days |  | 1403/2/14 | 1403/2/15 | 1403/2/28 | 1403/2/29 |
| 250 | 1.6.3.3 | تابلو های حفاظت و کنترل |  | 6d | 2026-07-26 | 2026-07-31 |  | 2026-02-27 | 2026-03-05 | 7d | 7d | 0d | start no earlier than 2026-07-26 | 2,402 | 2,402 | 1405/5/4 | 1405/5/9 | 6days |  | 1403/2/31 | 1403/3/6 | 1403/3/10 | 1403/3/16 |
| 251 | 1.6.3.4 | تابلو های فشار متوسط |  | 6d | 2026-08-01 | 2026-08-06 | 250 | 2026-03-06 | 2026-03-12 | 7d | 7d |  | start no earlier than 2024-07-13 | 2,402 | 2,402 | 1405/5/10 | 1405/5/15 | 6days |  | 1403/3/7 | 1403/3/13 | 1403/3/17 | 1403/3/23 |
| 252 | 1.6.3.5 | AC/DC تابلو های |  | 6d | 2026-08-14 | 2026-08-19 | 251 | 2026-02-27 | 2026-03-05 | 7d | 0d |  | start no earlier than 2026-08-14 | 1,201 | 1,201 | 1405/5/23 | 1405/5/28 | 6days | 1402/1/24 | 1403/3/11 | 1403/3/15 | 1403/3/24 | 1403/3/28 |
| 253 | 1.6.3.6 | تست عملکردی تجهیزات محوطه |  | 6d | 2026-08-20 | 2026-08-25 | 252 | 2026-02-20 | 2026-02-26 | 7d | 0d |  | start no earlier than 2026-07-26 | 2,402 | 2,402 | 1405/5/29 | 1405/6/3 | 6days | 1402/2/29 | 1403/2/23 | 1403/3/1 | 1403/2/6 | 1403/2/12 |
| 254 | 1.6.3.7 | اینترتریپ و اینترلاک |  | 6d | 2026-08-26 | 2026-08-31 | 253, 250FS-6d | 2026-02-28 | 2026-03-06 | 7d | 0d |  | start no earlier than 2024-07-13 | 1,201 | 1,201 | 1405/6/4 | 1405/6/9 | 6days | 1402/3/3 | 1403/3/7 | 1403/3/16 | 1403/3/17 | 1403/3/23 |
| 255 | 1.6.3.8 | تست عملکردی تابلو های حفاظت و کنترل |  | 7d | 2026-08-27 | 2026-09-02 | 250, 254FS-5d | 2026-03-06 | 2026-03-12 | 7d | 0d |  | start no earlier than 2024-07-13 | 1,201 | 1,201 | 1405/6/5 | 1405/6/11 | 7days | 1402/3/6 | 1403/3/18 | 1403/3/24 | 1403/3/31 | 1403/4/6 |
| 256 | 1.6.3.9 | رله های حفاظتی |  | 6d | 2026-08-29 | 2026-09-03 | 255FS-5d | 2026-03-08 | 2026-03-14 | 7d | 0d |  | start no earlier than 2024-07-13 | 3,603 | 3,603 | 1405/6/7 | 1405/6/12 | 6days | 1402/3/9 | 1403/3/25 | 1403/4/7 | 1403/4/7 | 1403/4/20 |
| 257 | 1.6.3.10 | پیوستگی جریان و ولتاژ |  | 7d | 2026-08-30 | 2026-09-05 | 256FS-5d, 251, 252 | 2026-03-13 | 2026-03-18 | 6d | 0d |  | start no earlier than 2026-07-21 | 1,201 | 1,201 | 1405/6/8 | 1405/6/14 | 7days | 1402/3/12 | 1403/4/8 | 1403/4/21 | 1403/4/21 | 1403/4/25 |
| 258 | 1.6.3.11 | رفع اشکالات |  | 1d | 2026-09-06 | 2026-09-06 | 257, 249 | 2026-03-19 | 2026-03-19 | 1d | 0d |  | start no earlier than 2026-08-17 | 1,201 | 1,201 | 1405/6/15 | 1405/6/15 | 1days | 1402/3/16 | 1403/4/22 | 1403/4/22 | 1403/4/26 | 1403/4/30 |
| 259 | 1.6.3.12 | برقداری |  | 1d | 2026-09-07 | 2026-09-07 | 258, 249 | 2026-03-20 | 2026-03-20 | 1d | 0d |  | start no earlier than 2024-07-13 | 1,202 | 1,202 | 1405/6/16 | 1405/6/16 | 1days | 1402/3/18 | 1403/4/22 | 1403/4/23 | 1403/4/31 | 1403/5/3 |
| 260 | 1.7 | پایان پروژه طبق قرارداد | milestone | 0d | 2026-09-07 | 2026-09-07 | 259 |  |  |  | 0d |  |  |  |  | 1405/6/16 | 1405/6/16 | 0days |  |  |  |  |  |
